# ESTUDIOS, DISEÑOS, CONSTRUCCIÓN Y MANTENIMIENTO DE INFRAESTRUCTURA FÍSICA EN INSTITUCIONES EDUCATIVAS DEL MUNICIPIO DE MONTERÍA

Schedule from MS Project, 2025-05-23 to 2026-10-06, costs in $.

## Calendars

- EDUCATIVO: Mon-Sun 07:00-12:00, 14:00-17:00.

## Schedule

| ID | WBS | Task | Type | Duration | Start | Finish | Predecessors | Total slack | Free slack | Cost |
| --- | --- | --- | --- | --- | --- | --- | --- | --- | --- | --- |
| 1 | 1 | INICIO FASE 3 | milestone | 0d | 2025-05-23 | 2025-05-23 |  | 31d | 0d |  |
| 2 | 6 | INICIO | milestone | 0d | 2026-05-04 | 2026-05-04 | 1 | 21d | 0d |  |
| 3 | 6 | INICIO | milestone | 0d | 2025-08-22 | 2025-08-22 | 1 | 80d | 0d |  |
| 4 | 6 | INICIO | milestone | 0d | 2025-06-28 | 2025-06-28 | 1 | 129d | 0d |  |
| 5 | 6 | INICIO | milestone | 0d | 2025-05-23 | 2025-05-23 | 1 | 101.75d | 0d |  |
| 6 | 6 | INICIO | milestone | 0d | 2025-05-23 | 2025-05-23 | 1 | 108.75d | 0d |  |
| 7 | 6 | INICIO | milestone | 0d | 2025-05-23 | 2025-05-23 | 1 | 31d | 0d |  |
| 8 | 6 | INICIO | milestone | 0d | 2025-05-23 | 2025-05-23 | 1 | 158.75d | 0d |  |
| 9 | 7 | INICIO | milestone | 0d | 2025-05-23 | 2025-05-23 | 1 | 164.75d | 0d |  |
| 10 | 7 | INICIO | milestone | 0d | 2025-05-23 | 2025-05-23 | 1 | 181.75d | 0d |  |
| 11 | 7 | INICIO | milestone | 0d | 2025-05-23 | 2025-05-23 | 1 | 186.75d | 0d |  |
| 12 | 7 | INICIO | milestone | 0d | 2025-05-23 | 2025-05-23 | 1 | 206.75d | 0d |  |
| 13 | 7 | INICIO | milestone | 0d | 2025-05-23 | 2025-05-23 | 1 | 301.75d | 0d |  |
| 14 | 7 | INICIO | milestone | 0d | 2025-05-23 | 2025-05-23 | 1 | 311.75d | 0d |  |
| 15 | 7 | INICIO | milestone | 0d | 2025-05-23 | 2025-05-23 | 1 | 326.75d | 0d |  |
| 16 | 7 | INICIO | milestone | 0d | 2025-05-23 | 2025-05-23 | 1 | 346.75d | 0d |  |
| 17 | 17 | CAÑO VIEJO |  | 155d | 2025-05-23 | 2025-10-25 |  | 346.75d |  | 1,776,244,516.78 |
| 18 | 18 | CAMILO LAMADRID |  | 176d | 2025-05-23 | 2025-11-15 |  | 325.75d |  | 2,918,781,537.87 |
| 19 | 19 | EL RECUERDO |  | 190d | 2025-05-23 | 2025-11-29 |  | 311.75d |  | 3,154,171,583.53 |
| 20 | 20 | SANTA ROSA DE LIMA |  | 204d | 2025-05-23 | 2025-12-13 |  | 297.75d |  | 2,015,126,169.24 |
| 21 | 21 | GARZONES |  | 295d | 2025-05-23 | 2026-03-14 |  | 206.75d |  | 2,551,410,717.67 |
| 22 | 22 | CRISTOBAL COLON |  | 316d | 2025-05-23 | 2026-04-04 |  | 185.75d |  | 5,017,761,896.68 |
| 23 | 23 | GUILLERMO VALENCIA SEDE PRINCIPAL |  | 323d | 2025-05-23 | 2026-04-11 |  | 178.75d |  | 4,718,481,937.92 |
| 24 | 24 | PAZ DEL NORTE |  | 337d | 2025-05-23 | 2026-04-25 |  | 164.75d |  | 1,911,261,036.14 |
| 25 | 25 | ANEXA |  | 344d | 2025-05-23 | 2026-05-02 |  | 157.75d |  | 2,274,729,220.65 |
| 26 | 26 | MOCHILA |  | 351d | 2025-05-23 | 2026-05-09 |  | 31d |  | 1,649,002,596.07 |
| 27 | 27 | EL TIGRE |  | 337d | 2025-06-28 | 2026-05-30 |  | 129d |  | 4,732,036,958.82 |
| 28 | 28 | IPC |  | 289d | 2025-08-22 | 2026-06-06 |  | 80d |  | 3,102,781,855.11 |
| 29 | 29 | ALIVIO |  | 393d | 2025-05-23 | 2026-06-20 |  | 108.75d |  | 2,289,861,187.74 |
| 30 | 30 | ARROYON |  | 400d | 2025-05-23 | 2026-06-27 |  | 101.75d |  | 2,115,679,217.91 |
| 31 | 31 | MARIA GORETTI |  | 219d | 2026-03-02 | 2026-10-06 |  | 0d |  | 2,647,353,047.59 |
| 32 | 32 | SANTA MARIA |  | 135d | 2026-05-04 | 2026-09-15 |  | 21d |  | 592,023,929 |
| 33 | 33 | CECILIA DE LLERAS |  | 130d | 2026-03-23 | 2026-07-30 |  | 68d |  | 1,175,331,031 |
| 34 | 34 | ISABEL LA CATOLICA |  | 125d | 2026-03-23 | 2026-07-25 |  | 73d |  | 1,439,623,128 |
| 35 | 35 | INMACULADA |  | 65d | 2026-03-23 | 2026-05-26 |  | 133d |  | 154,342,288 |
| 36 | 36 | SABANAL |  | 110d | 2026-03-23 | 2026-07-10 |  | 50d |  | 244,681,605 |
| 37 | 37 | LETICIA |  | 75d | 2026-03-23 | 2026-06-05 |  | 123d |  | 263,398,523 |
| 38 | 25 | FIN | milestone | 0d | 2025-10-25 | 2025-10-25 |  | 346.75d |  |  |
| 39 | 23 | FIN | milestone | 0d | 2025-11-15 | 2025-11-15 |  | 325.75d |  |  |
| 40 | 12 | FIN | milestone | 0d | 2025-11-29 | 2025-11-29 |  | 311.75d |  |  |
| 41 | 19 | FIN | milestone | 0d | 2025-12-13 | 2025-12-13 |  | 297.75d |  |  |
| 42 | 19 | FIN | milestone | 0d | 2026-03-14 | 2026-03-14 |  | 206.75d |  |  |
| 43 | 22 | FIN | milestone | 0d | 2026-04-04 | 2026-04-04 |  | 185.75d |  |  |
| 44 | 23 | FIN | milestone | 0d | 2026-04-11 | 2026-04-11 |  | 178.75d |  |  |
| 45 | 24 | FIN | milestone | 0d | 2026-04-25 | 2026-04-25 |  | 164.75d |  |  |
| 46 | 19 | FIN | milestone | 0d | 2026-05-02 | 2026-05-02 |  | 157.75d |  |  |
| 47 | 24 | FIN | milestone | 0d | 2026-05-09 | 2026-05-09 |  | 150.75d |  |  |
| 48 | 26 | FIN | milestone | 0d | 2026-05-30 | 2026-05-30 |  | 129d |  |  |
| 49 | 24 | FIN | milestone | 0d | 2026-06-06 | 2026-06-06 |  | 122d |  |  |
| 50 | 24 | FIN | milestone | 0d | 2026-06-20 | 2026-06-20 |  | 108.75d |  |  |
| 51 | 23 | FIN | milestone | 0d | 2026-06-27 | 2026-06-27 |  | 101.75d |  |  |
| 52 | 16 | FIN | milestone | 0d | 2026-10-06 | 2026-10-06 |  | 0d |  |  |
| 53 | 10 | FIN | milestone | 0d | 2026-09-15 | 2026-09-15 |  | 21d |  |  |
| 54 | 7 | FIN | milestone | 0d | 2026-07-30 | 2026-07-30 |  | 68d |  |  |
| 55 | 55 | FIN | milestone | 0d | 2026-10-06 | 2026-10-06 | 38, 39, 40, 41, 42, 43, 44, 45, 46, 47, 48, 49, 50, 51, 52, 53, 54 | 0d |  |  |
